| id | name | startDate | endDate | priority | barScale | progress | type | parentId | dependencies |
| --- | --- | --- | --- | --- | --- | --- | --- | --- | --- |
| 1 | Clinical Trial | 2026-06-01T00:00:00.000Z | 2027-12-01T00:00:00.000Z | medium | 1 | 0 | group |  |  |
| 2 | Protocol design | 2026-06-01T00:00:00.000Z | 2026-07-31T00:00:00.000Z | high | 1 | 0 | task | 1 |  |
| 3 | CRO and vendor selection | 2026-06-01T00:00:00.000Z | 2026-07-21T00:00:00.000Z | medium | 1 | 0 | task | 1 |  |
| 4 | Statistical analysis plan | 2026-07-01T00:00:00.000Z | 2026-08-15T00:00:00.000Z | medium | 1 | 0 | task | 1 |  |
| 5 | Case report form design | 2026-07-31T00:00:00.000Z | 2026-08-30T00:00:00.000Z | medium | 1 | 0 | task | 1 | 2 FS |
| 6 | IRB/ethics submission | 2026-07-31T00:00:00.000Z | 2026-08-20T00:00:00.000Z | medium | 1 | 0 | task | 1 | 2 FS |
| 7 | Regulatory filing | 2026-08-05T00:00:00.000Z | 2026-08-30T00:00:00.000Z | medium | 1 | 0 | task | 1 | 2 FS |
| 8 | Register trial | 2026-08-25T00:00:00.000Z | 2026-08-30T00:00:00.000Z | medium | 1 | 0 | task | 1 | 4 FS |
| 9 | Site selection and contracts | 2026-08-30T00:00:00.000Z | 2026-11-08T00:00:00.000Z | medium | 1 | 0 | task | 1 | 3 FS |
| 10 | IRB/ethics approval | 2026-09-19T00:00:00.000Z | 2026-09-20T00:00:00.000Z | high | 1 | 0 | milestone | 1 | 6 FS |
| 11 | Ship investigational product | 2026-10-19T00:00:00.000Z | 2026-11-13T00:00:00.000Z | medium | 1 | 0 | task | 1 | 10 FS |
| 12 | Investigator and site training | 2026-11-08T00:00:00.000Z | 2026-11-28T00:00:00.000Z | medium | 1 | 0 | task | 1 | 9 FS |
| 13 | Participant recruitment and screening | 2026-11-28T00:00:00.000Z | 2027-01-27T00:00:00.000Z | medium | 1 | 0 | task | 1 | 12 FS |
| 14 | First patient enrolled | 2026-12-13T00:00:00.000Z | 2026-12-14T00:00:00.000Z | high | 1 | 0 | milestone | 1 | 12 FS |
| 15 | Treatment and dosing period | 2026-12-14T00:00:00.000Z | 2027-10-09T00:00:00.000Z | high | 1 | 0 | task | 1 | 14 FS |
| 16 | Data collection and monitoring visits | 2026-12-18T00:00:00.000Z | 2027-10-14T00:00:00.000Z | medium | 1 | 0 | task | 1 | 14 FS |
| 17 | Interim analysis | 2027-06-06T00:00:00.000Z | 2027-06-26T00:00:00.000Z | medium | 1 | 0 | task | 1 |  |
| 18 | Last patient out | 2027-10-09T00:00:00.000Z | 2027-10-10T00:00:00.000Z | high | 1 | 0 | milestone | 1 | 15 FS |
| 19 | Database lock | 2027-10-19T00:00:00.000Z | 2027-10-20T00:00:00.000Z | medium | 1 | 0 | milestone | 1 | 18 FS |
| 20 | Statistical analysis | 2027-10-20T00:00:00.000Z | 2027-11-14T00:00:00.000Z | medium | 1 | 0 | task | 1 | 19 FS |
| 21 | Final study report | 2027-11-14T00:00:00.000Z | 2027-12-01T00:00:00.000Z | medium | 1 | 0 | task | 1 | 20 FS |
